# План работ 20080414

Schedule from MS Project, 2008-04-10 to 2009-06-22.
bft

## Calendars

- Стандартный: Mon-Fri 09:00-13:00, 14:00-18:00; Sat-Sun off.

## Resources

| Resource |
| --- |
| Оператор |
| Россвязьохранкультура |
| Застройщик |
| Приемочная Комиссия |
| Проектная организация |
| Главгосэкспертиза |
| Строительно-монтажная организация |
| Роспотребнадзор |
| ОАО МГТС |
| Аккредитованные лаборатории |
| Комитет общественных связей города Москвы |
| Аккредитованное лицо на проведение экспертизы системного проекта сети связи |
| Ростелеком |
| ФАС |

## Schedule

| ID | WBS | Task | Duration | Start | Finish | Predecessors | Total slack | Free slack | Resources |
| --- | --- | --- | --- | --- | --- | --- | --- | --- | --- |
| 1 | 1 | **Выполнить ПИР инфраструктуры сети связи** | 35d | 2008-04-10 | 2008-05-28 |  | 0d |  | Застройщик |
| 2 | 1.1 | Утвердить рабочую документацию по архитектурно-строительной подготовке | 15d | 2008-04-10 | 2008-04-30 |  | 0d |  | Застройщик |
| 3 | 1.2 | Утвердить рабочую документацию по системам вентиляции и кондиционирования | 15d | 2008-04-10 | 2008-04-30 |  | 45d |  | Застройщик |
| 4 | 1.3 | Утвердить рабочую документацию по системам пожартушения | 35d | 2008-04-10 | 2008-05-28 |  | 51d | 25d | Застройщик |
| 5 | 1.4 | Утвердить рабочую документацию по системе диспетчеризации | 15d | 2008-04-10 | 2008-04-30 |  | 56d | 45d | Застройщик |
| 6 | 1.5 | Утвердить рабочую документацию по системе электроснабжения | 20d | 2008-04-10 | 2008-05-07 |  | 40d |  | Застройщик |
| 7 | 37 | **Выполнить СМР и ПНР инфраструктуры сети связи** | 111d? | 2008-05-01 | 2008-10-02 |  | 0d |  | Строительно-монтажная организация |
| 8 | 2.1 | Выполнить работы по архитектурно-строительной подготовке | 45d | 2008-05-01 | 2008-07-02 | 2 | 0d |  | Строительно-монтажная организация |
| 9 | 2.2 | Выполнить СМР и ПНР систем вентиляции и кондиционирования | 66d | 2008-07-03 | 2008-10-02 | 3, 8 | 0d |  | Строительно-монтажная организация |
| 10 | 2.3 | Выполнить СМР и ПНР систем пожаротушения | 40d | 2008-07-03 | 2008-08-27 | 4, 8 | 26d |  | Строительно-монтажная организация |
| 11 | 2.4 | Выполнить СМР и ПНР систем диспетчеризации | 55d | 2008-07-03 | 2008-09-17 | 8, 5 | 11d |  | Строительно-монтажная организация |
| 12 | 37.2 | **Выполнить СМР и ПНР по энергоснабжению** | 66d? | 2008-07-03 | 2008-10-02 | 6, 8 | 0d |  | Строительно-монтажная организация |
| 13 | 2.5.1 | Выполнить СМР и ПНР оборудования электроснабжения | 66d | 2008-07-03 | 2008-10-02 |  | 0d |  | Строительно-монтажная организация |
| 14 | 2.5.2 | **Оформить документы по электрооснабжению** | 1d? | 2008-07-03 | 2008-07-03 |  | 65d |  | Оператор |
| 15 | 2.5.2.1 | Назначить приказом руководителя оператора связи лицо, ответственное за электрохозяйство оператора | 1d? | 2008-07-03 | 2008-07-03 |  | 65d |  | Оператор |
| 16 | 2.5.2.2 | Оформить протоколы измерений параметров электроустановок | 1d? | 2008-07-03 | 2008-07-03 |  | 65d |  | Оператор |
| 17 | 2.5.2.3 | Оформить паспорт на заземляющее устройство | 1d? | 2008-07-03 | 2008-07-03 |  | 65d |  | Оператор |
| 18 | 2.5.2.4 | Утвердить Акт допуска электроустановки к эксплуатации | 1d? | 2008-07-03 | 2008-07-03 |  | 65d |  | Оператор |
| 19 | 2.5.2.5 | Получить копии аттестатов аккредитации электроизмерительных лабораторий | 1d? | 2008-07-03 | 2008-07-03 |  | 65d |  | Оператор |
| 20 | 2.5.2.6 | Составить Акт разграничения балансовой принадлежности между энергоснабжающей организацией и потребителем | 1d? | 2008-07-03 | 2008-07-03 |  | 65d |  | Оператор; Застройщик |
| 21 | 25 | **Зарегистрировать лицензии в Россвязьохранкультуре** | 1d? | 2008-04-10 | 2008-04-10 |  | 245d |  | Оператор; Россвязьохранкультура |
| 22 | 25.6 | **Предоставить документы для регистрации лицензий в Россвязьохранкультуру** | 1d? | 2008-04-10 | 2008-04-10 |  | 245d |  | Оператор |
| 23 | 25.6.a | Предоставить заявления (сопроводительного письма) с просьбой о регистрации | 1d? | 2008-04-10 | 2008-04-10 |  | 245d |  | Оператор |
| 24 | 25.6.b | Предоставить копии лицензий | 1d? | 2008-04-10 | 2008-04-10 |  | 245d |  | Оператор |
| 25 | 25.6.c | Предоставить реквизиты лицензиата | 1d? | 2008-04-10 | 2008-04-10 |  | 245d |  | Оператор |
| 26 | 25.6.d | Копии Свидетельства о регистрации лицензиата как юридического лица | 1d? | 2008-04-10 | 2008-04-10 |  | 245d |  | Оператор |
| 27 | 25.6.e | Предоставить копии карты постановки на налоговый учет | 1d? | 2008-04-10 | 2008-04-10 |  | 245d |  | Оператор |
| 28 | 25.7 | Внесение сведений в базу данных лицензиатов | 1d? | 2008-04-10 | 2008-04-10 |  | 245d |  | Россвязьохранкультура |
| 29 | 25.8 | Выдача оператору связи Свидетельства о регистрации лицензиата | 1d? | 2008-04-10 | 2008-04-10 |  | 245d |  | Россвязьохранкультура |

Notes:
- 21: пп. 3.1., 3.2., приложение 1 Приказа Главгоссвязьнадзора России от 03.03.1999 №11
- 22: п. 4 приложения 1 Приказа Главгоссвязьнадзора России от 03.03.1999 №11
- 23: п. 4.1. приложения 1 Приказа Главгоссвязьнадзора России от 03.03.1999 №11
- 24: п. 4.2. приложения 1 Приказа Главгоссвязьнадзора России от 03.03.1999 №11
- 25: п. 4.4. приложения 1 Приказа Главгоссвязьнадзора России от 03.03.1999 №11
- 26: п. 4.5. приложения 1 Приказа Главгоссвязьнадзора России от 03.03.1999 №11
- 27: п. 4.6. приложения 1 Приказа Главгоссвязьнадзора России от 03.03.1999 №11
- 28: п. 5.1. приложения 1 Приказа Главгоссвязьнадзора России от 03.03.1999 №11
- 29: п. 5.2. приложения 1 Приказа Главгоссвязьнадзора России от 03.03.1999 №11

| ID | WBS | Task | Duration | Start | Finish | Predecessors | Total slack | Free slack | Resources |
| --- | --- | --- | --- | --- | --- | --- | --- | --- | --- |
| 30 | 54 | **Получить доступ к ограниченным ресурсам связи** | 30d? | 2008-04-10 | 2008-05-21 |  | 216d |  | Оператор |
| 31 | 54.1 | Получить в ФАС ресурс нумерации | 1d? | 2008-04-10 | 2008-04-10 |  | 244d | 94d | Оператор |
| 32 | 54.2 | Получить в ФАС номера пунктов сигнализации сети ОКС 7 | 1d | 2008-04-10 | 2008-04-10 |  | 245d |  | Оператор |
| 33 | 54.3 | **Получить разрешение органов ГРЧС на использование радиочастот** | 30d | 2008-04-10 | 2008-05-21 |  | 216d |  | Оператор |
| 34 | 54.3.a | Получить Решение ГКРЧ о выделении полос частот для эксплуатации РЭС | 30d | 2008-04-10 | 2008-05-21 |  | 216d |  | Оператор |
| 35 | 54.3.b | Получить заключение об электромагнитной совместимости с РЭС гражданского и негражданского назначения | 30d | 2008-04-10 | 2008-05-21 |  | 216d |  | Оператор |
| 36 | 54.3.c | Получить частотные назначения для эксплуатации РЭС | 22d | 2008-04-10 | 2008-05-09 |  | 224d |  | Оператор |
| 37 | 22 | **Разработать системный проект сети связи БФТ** | 131d? | 2008-04-10 | 2008-10-09 |  | 41d | 115d | Проектная организация |
| 38 | 22.1 | Разработать ТЗ на разработку системного проекта | 10d | 2008-04-10 | 2008-04-23 |  | 41d | 0d | Оператор; Проектная организация |
| 39 | 22.2 | Заключить договор на разработку проекта сети связи | 10d | 2008-04-24 | 2008-05-07 | 38 | 41d | 0d | Оператор; Проектная организация |
| 40 | 22.3 | Разработать системный проект сети связи | 45d | 2008-05-08 | 2008-07-09 | 39 | 41d | 0d | Проектная организация |
| 41 | 22.4 | **Провести экспертизу системного проекта сети связи** | 66d? | 2008-07-10 | 2008-10-09 | 40 | 115d |  | Проектная организация |
| 42 | 22.4.a | **Предоставить документы для проведения государственной экспертизы** | 20d? | 2008-07-10 | 2008-08-06 |  | 161d |  | Проектная организация |
| 43 | 22.4.a.1 | Предоставить заявление на проведение экспертизы системного проекта | 1d? | 2008-07-10 | 2008-07-10 |  | 180d |  | Проектная организация |
| 44 | 22.4.a.3 | Предоставить документы, подтверждающие полномочия заявителя действовать от имени заказчика системного проекта | 1d? | 2008-07-10 | 2008-07-10 |  | 180d |  | Проектная организация |
| 45 | 22.4.a.11 | Предоставить заверенную подписью и печатью заказчика копию задания на разработку системного проекта сети электросвязи | 1d? | 2008-07-10 | 2008-07-10 |  | 180d |  | Проектная организация |
| 46 | 22.4.a.12 | Предоставить заверенную подписью и печатью заказчика копию исходных данных, использовавшихся для подготовки системного проекта | 1d? | 2008-07-10 | 2008-07-10 |  | 180d |  | Проектная организация |
| 47 | 22.4.a.13 | Предоставить системный проект | 1d? | 2008-07-10 | 2008-07-10 |  | 180d |  | Проектная организация |
| 48 | 22.4.a.14 | Предоставить технические условия, в том числе на присоединение к сети связи общего пользования | 1d? | 2008-07-10 | 2008-07-10 |  | 180d |  | Проектная организация |
| 49 | 22.4.a.15 | Предоставить копии сертификатов соответствия (декларации о соответствии) на средства связи, используемые в проекте | 1d? | 2008-07-10 | 2008-07-10 |  | 180d |  | Проектная организация |
| 50 | 22.4.a.16 | Предоставить лицензию юридического лица, разработавшего проектную документацию | 1d? | 2008-07-10 | 2008-07-10 |  | 180d |  |  |
| 51 | 22.4.a.18 | Предоставить лицензии оператора на оказание услуг связи | 1d? | 2008-07-10 | 2008-07-10 |  | 180d |  |  |
| 52 | 22.4.a.17 | **Проверка документов, представленных для проведения государственной экспертизы** | 20d | 2008-07-10 | 2008-08-06 |  | 161d |  | Аккредитованное лицо на проведение экспертизы системного проекта сети связи |
| 53 | 22.4.a.17.6 | Проверка представленных документов | 3d | 2008-07-10 | 2008-07-14 |  | 178d |  | Аккредитованное лицо на проведение экспертизы системного проекта сети связи |
| 54 | 22.4.a.17.7 | Направление проекта договора на проведение экспертизы системного проекта сети связи | 5d | 2008-07-10 | 2008-07-16 |  | 176d |  | Аккредитованное лицо на проведение экспертизы системного проекта сети связи |
| 55 | 22.4.a.17.8 | Устранение недостатков в представленных документах | 20d | 2008-07-10 | 2008-08-06 |  | 161d |  | Проектная организация |
| 56 | 22.4.f | Заключение договора на проведение экспертизы системного проекта сети связи | 7d | 2008-07-10 | 2008-07-18 |  | 174d |  | Проектная организация |
| 57 | 22.4.i | Внесение платы за проведение экспертизы системного проекта сети связи в соответствии с договором | 1d? | 2008-07-10 | 2008-07-10 |  | 180d |  | Проектная организация |
| 58 | 22.4.e | Проведение экспертизы системного проекта сети связи | 66d | 2008-07-10 | 2008-10-09 |  | 115d |  | Аккредитованное лицо на проведение экспертизы системного проекта сети связи |
| 59 | 22.8 | Утверждение системного проекта сети связи | 5d | 2008-04-10 | 2008-04-16 |  | 241d |  | Оператор |

Notes:
- 33: п. 4.3. Приказа Минсвязи от 9.09.2002 №113
- 38: Заданием на проектирование должна предусматриваться разработка эксплуатационной документации
- 40: Федеральный Закон Российской Федерации от 09.02.2007 №14-ФЗ "О внесении изменений в Федеральный Закон "О связи"" / ст. 43.1 Федерального Закона Российской Федерации от 07.07.2003 №126-ФЗ "О связи"
- 41: Правила проведения экспертизы системного проекта сети связи по состоянию на 10.01.2007 не определены, однако вытекают из / -Федерального Закона Российской Федерации от 09.02.2007 №14-ФЗ "О внесении изменений в Федеральный Закон "О связи""; / - ст. 43.1 Федерального Закона Российской Федерации от 07.07.2003 №126-ФЗ "О связи". / Приказ Минсвязи от 22.07.2003 №96
- 42: глава II Положения об организации и проведении государственной экспертизы проектной документации и результатов инженерных изысканий (утверждены Постановлением Правительства Российской Федерации от 05.03.2007 №145)
- 43: п. 4 Проекта правил проведения экспертизы системных проектов сетей связи
- 44: п. 5 Проекта правил проведения экспертизы системных проектов сетей связи
- 45: п. 5 Проекта правил проведения экспертизы системных проектов сетей связи
- 46: п. 5 Проекта правил проведения экспертизы системных проектов сетей связи
- 47: п. 5 Проекта правил проведения экспертизы системных проектов сетей связи / п. 3.1.1. Приказа Минсвязи РФ от 22.07.2003 №96
- 48: п. 3.1.2. Приказа Минсвязи РФ от 22.07.2003 №96
- 49: п. 3.1.3. Приказа Минсвязи РФ от 22.07.2003 №96
- 50: п. 3.1.4. Приказа Минсвязи РФ от 22.07.2003 №96
- 51: п. 13. Проекта правил проведения экспертизы системных проектов сетей связи
- 52: Проект правил проведения экспертизы системных проектов сетей связи
- 53: Проект правил проведения экспертизы системных проектов сетей связи
- 54: Проект правил проведения экспертизы системных проектов сетей связи
- 55: Проект правил проведения экспертизы системных проектов сетей связи
- 56: Проект правил проведения экспертизы системных проектов сетей связи
- 57: Проект правил проведения экспертизы системных проектов сетей связи
- 58: Проект правил проведения экспертизы системных проектов сетей связи
- 59: Утверждение системного проекта сети связи осуществляется приказом

| ID | WBS | Task | Duration | Start | Finish | Predecessors | Total slack | Free slack | Resources |
| --- | --- | --- | --- | --- | --- | --- | --- | --- | --- |
| 60 | 65 | **Получить ТУ на присоединение к сетям связи** | 30d | 2008-07-10 | 2008-08-20 | 40 | 41d | 0d | Оператор; Проектная организация |
| 61 | 65.1 | получить ТУ в ОАО "МГТС" | 30d | 2008-07-10 | 2008-08-20 |  | 41d |  | Оператор; Проектная организация |
| 62 | 65.2 | получить ТУ в ОАО "Ростелеком" | 30d | 2008-07-10 | 2008-08-20 |  | 41d |  | Оператор; Проектная организация |
| 63 | 65.3 | получить ТУ для ММТС-9 | 30d | 2008-07-10 | 2008-08-20 |  | 41d |  | Оператор; Проектная организация |
| 64 | 65.4 | получить ТУ для ММТС-10 | 30d | 2008-07-10 | 2008-08-20 |  | 41d |  | Оператор; Проектная организация |
| 65 | 65.5 | получить ТУ по СОРМ в ФСБ | 30d | 2008-07-10 | 2008-08-20 |  | 41d | 0d | Оператор; Проектная организация |
| 66 | 64 | **Разработать рабочую документацию сети связи** | 45d | 2008-08-21 | 2008-10-22 | 40, 60 | 41d | 0d | Проектная организация |
| 67 | 64.1 | Разработать ПСД по СТфС | 45d | 2008-08-21 | 2008-10-22 |  | 41d |  | Проектная организация |
| 68 | 64.2 | Разработать ПСД по СПД | 45d | 2008-08-21 | 2008-10-22 |  | 41d |  | Проектная организация |
| 69 | 64.3 | Разработать ПСД по СКС | 45d | 2008-08-21 | 2008-10-22 |  | 41d |  | Проектная организация |
| 70 | 64.4 | Разработать проект по внедрению системы управления сетью электросвязи | 45d | 2008-08-21 | 2008-10-22 |  | 41d |  | Проектная организация |
| 71 | 64.5 | Разработать проект по внедрению системы биллинга | 45d | 2008-08-21 | 2008-10-22 |  | 41d |  | Проектная организация |
| 72 | 58 | **Разработать план мероприятий по СОРМ** | 50d | 2008-08-21 | 2008-10-29 | 65 | 101d |  | Оператор; Проектная организация |
| 73 | 58.1 | Согласовать план мероприятий СОРМ с ФСБ | 20d | 2008-08-21 | 2008-09-17 |  | 101d | 0d |  |
| 74 | 58.2 | Ввести ТСС СОРМ в эксплутацию | 20d | 2008-09-18 | 2008-10-15 | 73 | 101d | 0d |  |
| 75 | 58.3 | получить письмо от ФСБ об отсутствии замечаний к вводу в эксплуатацию | 10d | 2008-10-16 | 2008-10-29 | 74 | 101d |  |  |
| 76 | 3 | **Уведомить Россвязьохранкультуры о начале работ по созданию нового сооружения связи сети связи** | 10d? | 2009-01-02 | 2009-01-15 | 163 | 35d | 0d | Оператор |
| 77 | 3.12 | Направить уведомление о начале работ по созданию нового сооружения связи | 1d? | 2009-01-02 | 2009-01-02 |  | 44d |  | Оператор |
| 78 | 3.9 | **Предоставить дополнительные документы** | 1d? | 2009-01-02 | 2009-01-02 |  | 44d |  | Оператор |
| 79 | 3.9.a | предоставить лицензии на вид деятельности по оказанию услуг связи | 1d? | 2009-01-02 | 2009-01-02 |  | 44d |  | Оператор |
| 80 | 9.2.2 | предоставить свидетельство о регистрации лицензиата | 1d? | 2009-01-02 | 2009-01-02 |  | 44d |  | Оператор |
| 81 | 3.9.b | предоставить разрешение на использование радиочастот для установки РЭС на объекте связи | 1d? | 2009-01-02 | 2009-01-02 |  | 44d |  | Оператор |
| 82 | 9.2.4 | предоставить краткую пояснительную записку (наименование, местонахождение, техническое описание объекта, титул проектной документации и наимнование проектной организации) | 1d? | 2009-01-02 | 2009-01-02 |  | 44d |  | Оператор |
| 83 | 9.2.5 | предоставить схему организации связи | 1d? | 2009-01-02 | 2009-01-02 |  | 44d |  | Оператор |
| 84 | 9.2.6 | предоставить перечень оборудования из спецификации проекта (будет указано в разрешении на эксплуатацию) | 1d? | 2009-01-02 | 2009-01-02 |  | 44d |  | Оператор |
| 85 | 3.9.c | предоставить утвержденную проектную документацию | 1d? | 2009-01-02 | 2009-01-02 |  | 44d |  | Оператор |
| 86 | 3.9.d | предоставить заключение государственной экспертизы проекта | 1d? | 2009-01-02 | 2009-01-02 |  | 44d |  | Оператор |
| 87 | 3.9.e | предоставить копии лицензий на право выполнения проектных работ по связи у разработчика ПД и его соисполнителей | 1d? | 2009-01-02 | 2009-01-02 |  | 44d |  | Оператор |
| 88 | 3.9.f | предоставить договора оператора с подрядной организацией на производство СМР и ПНР работ на объекте связи с указанием сроков выполнения работ | 1d? | 2009-01-02 | 2009-01-02 |  | 44d |  | Оператор |
| 89 | 3.9.g | предоставить копии лицензий на право производства СМР и ПНР на объекте связи у организаций, выполняющих эти работы | 1d? | 2009-01-02 | 2009-01-02 |  | 44d |  | Оператор |
| 90 | 3.9.h | предоставить копии сертификатов соответствия Минсвязи России на технические средства | 1d? | 2009-01-02 | 2009-01-02 |  | 44d |  | Оператор |

Notes:
- 72: Приказ Министерства информационных технологий и связи Российской Федерации №5 Федеральная служба безопасности Российской Федерации №8 от 15.01.2008 «Об утверждении типовых требований к плану мероприятий по внедрению технических средств для проведения оперативно-розыскных мероприятий» / Приказ Министерства информационных технологий и связи Российской Федерации от 16.01.2008 г. №6 «Об утверждении требований к сетям электросвязи для проведения оперативно-розыскных мероприятий. Часть I. Общие требования»
- 76: п. 4.2. Приказа Минсвязи от 9.09.2002 №113
- 79: п.2.2. Приказа Минсвязи от 15.12.1993 №61 (утратил силу)
- 81: п.2.2. Приказа Минсвязи от 15.12.1993 №61 (утратил силу)
- 85: п.2.2. Приказа Минсвязи от 15.12.1993 №61 (утратил силу)
- 86: п.2.2. Приказа Минсвязи от 15.12.1993 №61 (утратил силу)
- 87: п.2.2. Приказа Минсвязи от 15.12.1993 №61 (утратил силу)
- 88: п.2.2. Приказа Минсвязи от 15.12.1993 №61 (утратил силу)
- 89: п.2.2. Приказа Минсвязи от 15.12.1993 №61 (утратил силу)
- 90: п.2.2. Приказа Минсвязи от 15.12.1993 №61 (утратил силу)

| ID | WBS | Task | Duration | Start | Finish | Predecessors | Total slack | Resources |
| --- | --- | --- | --- | --- | --- | --- | --- | --- |
| 91 | 3.14 | **Заключить договора с Россвязьохранкультурой на выполнение работ по регистрации начала строительства, экспертизам законченных строительством объектов связи** | 1d? | 2009-01-02 | 2009-01-02 |  | 44d | Оператор; Россвязьохранкультура |
| 92 | 3.14.a | Заключить договор с Россвязьохранкультурой на выполнение работ по регистрации начала строительства объекта связи | 1d? | 2009-01-02 | 2009-01-02 |  | 44d | Оператор; Россвязьохранкультура |
| 93 | 3.14.b | Заключить договор с Россвязьохранкультурой на выполнение работ по экспертизам законченных строительством объектов связи | 1d? | 2009-01-02 | 2009-01-02 |  | 44d | Оператор; Россвязьохранкультура |
| 94 | 3.11 | Выдача оператору свидетельства о регистрации уведомления о начале работ по созданию нового сооружения связи в базе данных | 10d | 2009-01-02 | 2009-01-15 |  | 35d | Россвязьохранкультура |
| 95 | 5 | **Определить состав приемочной комиссии законченного строительством объекта недвижимости** | 10d? | 2009-01-16 | 2009-01-29 | 76 | 35d | Застройщик |
| 96 | 10.1 | **Пригласить представителя Россвязьохранкультуры** | 10d? | 2009-01-16 | 2009-01-29 |  | 35d | Оператор |
| 97 | 1 | Направить письмо с информацией об ожидаемых сроках ввода сооружения связи в эксплуатацию и просьбой о включении представителя органов Россвязьохранкультуры в состав приемочной комиссии УГНСИ | 1d? | 2009-01-16 | 2009-01-16 |  | 44d | Оператор |
| 98 | 2 | предложения о включении в состав приемочной комиссии представителя УГНСИ с указанием занимаемой должности | 10d | 2009-01-16 | 2009-01-29 |  | 35d | Россвязьохранкультура |
| 99 | 5.4 | Включить в состав рабочей комиссии представителей проектных организаций | 1d? | 2009-01-16 | 2009-01-16 |  | 44d | Оператор |
| 100 | 5.5 | Включить в состав рабочей комиссии представителей строительно-монтажных организаций | 1d? | 2009-01-16 | 2009-01-16 |  | 44d | Оператор |
| 101 | 5.3 | Подписание приказа о назначении приемочной комиссии | 1d? | 2009-01-16 | 2009-01-16 |  | 44d | Застройщик |
| 102 | 57 | **Выполнить присоединение сетей электросвязи** | 76d? | 2008-08-21 | 2008-12-04 | 60 | 75d | Оператор |
| 103 | 57.1 | **Заключить договор о присоединении сетей электросвязи** | 40d? | 2008-08-21 | 2008-10-15 |  | 111d | Оператор |
| 104 | 57.1.a | **Подготовить оферту о заключении договора о присоединении сетей электросвязи** | 1d? | 2008-08-21 | 2008-08-21 |  | 150d | Оператор |
| 105 | 57.1.a.21 | **Определить существенные условия присоединения сетей электросвязи** | 1d? | 2008-08-21 | 2008-08-21 |  | 150d | Оператор |
| 106 | 57.1.a.21.15 | **Определить технические существенные условия присоединения сетей электросвязи** | 1d? | 2008-08-21 | 2008-08-21 |  | 150d | Оператор |
| 107 | 57.1.a.21.15.20 | определить уровни присоединения | 1d? | 2008-08-21 | 2008-08-21 |  | 150d | Оператор |
| 108 | 57.1.a.21.15.21 | определить местонахождение точек присоединения сетей электросвязи | 1d? | 2008-08-21 | 2008-08-21 |  | 150d | Оператор |
| 109 | 57.1.a.21.15.22 | определить технические требования, касающиеся присоединения сетей электросвязи | 1d? | 2008-08-21 | 2008-08-21 |  | 150d | Оператор |
| 110 | 57.1.a.21.15.23 | определить объем, порядок и сроки выполнения работ по присоединению сетей электросвязи и их распределению между взаимодействующими операторами связи | 1d? | 2008-08-21 | 2008-08-21 |  | 150d | Оператор |
| 111 | 57.1.a.21.15.24 | определить порядок пропуска трафика по сетям электросвязи взаимодействующих операторов связи | 1d? | 2008-08-21 | 2008-08-21 |  | 150d | Оператор |
| 112 | 57.1.a.21.15.25 | определить порядок взаимодействия систем управления сетями электросвязи | 1d? | 2008-08-21 | 2008-08-21 |  | 150d | Оператор |
| 113 | 57.1.a.21.15.26 | определить порядок эксплуатационно-технического обслуживания средств связи и линий связи | 1d? | 2008-08-21 | 2008-08-21 |  | 150d | Оператор |
| 114 | 57.1.a.21.15.27 | определить порядок принятия мер по обеспечению устойчивого функционирования сетей связи, в том числе в чрезвычайных ситуациях | 1d? | 2008-08-21 | 2008-08-21 |  | 150d | Оператор |

Notes:
- 91: п. 9 Инструкции по контролю лицензируемой деятельности в области связи (утверждена Приказом Главгоссвязьнадзора России от 03.03.1999 №11) / п.1.6. Приказа Минсвязи от 15.12.1993 №61 (утратил силу)
- 92: п. 9 Инструкции по контролю лицензируемой деятельности в области связи (утверждена Приказом Главгоссвязьнадзора России от 03.03.1999 №11) / п.1.6. Приказа Минсвязи от 15.12.1993 №61 (утратил силу)
- 93: п. 9 Инструкции по контролю лицензируемой деятельности в области связи (утверждена Приказом Главгоссвязьнадзора России от 03.03.1999 №11) / п.1.6. Приказа Минсвязи от 15.12.1993 №61 (утратил силу)
- 94: п. 4.2. Приказа Минсвязи от 9.09.2002 №113 / п.1.5. Приказа Минсвязи от 15.12.1993 №61 (утратил силу) / пп.2.4., 2.5., 2.6., 2.7, 2.8. Приказа Минсвязи от 15.12.1993 №61 (утратил силу)
- 95: пп. 3.7., 3.13. Приказа Минсвязи от 9.09.2002 №113
- 96: п.2.8. Приказа Минсвязи от 15.12.1993 №61 (утратил силу)
- 97: п.2.8. Приказа Минсвязи от 15.12.1993 №61 (утратил силу)
- 98: п. 2.5. Приказа Минсвязи от 16.01.2003 №3 (утратил силу)
- 101: п. 3.1. Приказа Минсвязи от 16.01.2003 №3 (утратил силу)
- 103: Статья 18 Федерального Закона Российской Федерации "О связи"
- 104: Заключительные положения. Условия присоединения сетей электросвязи к сети электросвязи ОАО МГТС и условия пропуска трафика на местном уровне присоединения
- 105: Заключительные положения. Условия присоединения сетей электросвязи к сети электросвязи ОАО МГТС и условия пропуска трафика на местном уровне присоединения
- 106: п. 39 Постановления Правительства РФ от 28.03.2005 №161
- 107: п. 39 Постановления Правительства РФ от 28.03.2005 №161
- 108: пункт 3 статьи 19 Федерального Закона Российской Федерации от 07.07.2003 №126-ФЗ "О связи" / п. 6. Заключительные положения. Условия присоединения сетей электросвязи к сети электросвязи ОАО МГТС и условия пропуска трафика на местном уровне присоединения / п. 39 Постановления Правительства РФ от 28.03.2005 №161
- 109: п. 39 Постановления Правительства РФ от 28.03.2005 №161
- 110: пункт 3 статьи 18 Федерального Закона Российской Федерации от 07.07.2003 №126-ФЗ "О связи" / пункт 3 статьи 19 Федерального Закона Российской Федерации от 07.07.2003 №126-ФЗ "О связи" / п. 39 Постановления Правительства РФ от 28.03.2005 №161
- 111: пункт 3 статьи 18 Федерального Закона Российской Федерации от 07.07.2003 №126-ФЗ "О связи" / пункт 3 статьи 19 Федерального Закона Российской Федерации от 07.07.2003 №126-ФЗ "О связи" / п. 39 Постановления Правительства РФ от 28.03.2005 №161
- 112: пункт 3 статьи 19 Федерального Закона Российской Федерации от 07.07.2003 №126-ФЗ "О связи" / п. 39 Постановления Правительства РФ от 28.03.2005 №161
- 113: п. 39 Постановления Правительства РФ от 28.03.2005 №161
- 114: п. 39 Постановления Правительства РФ от 28.03.2005 №161

| ID | WBS | Task | Duration | Start | Finish | Predecessors | Total slack | Resources |
| --- | --- | --- | --- | --- | --- | --- | --- | --- |
| 115 | 57.1.a.21.16 | **Определить экономические условия присоединения сетей электросвязи** | 1d? | 2008-08-21 | 2008-08-21 |  | 150d | Оператор |
| 116 | 57.1.a.21.16.9 | определить перечень оказываемых услуг присоединения и услуг по пропуску трафика | 1d? | 2008-08-21 | 2008-08-21 |  | 150d | Оператор |
| 117 | 57.1.a.21.16.10 | определить стоимость услуг присоединения и услуг по пропуску трафика и порядок расчетов за них | 1d? | 2008-08-21 | 2008-08-21 |  | 150d | Оператор |
| 118 | 57.1.a.21.17 | **Определить информационные условия присоединения сетей электросвязи** | 1d? | 2008-08-21 | 2008-08-21 |  | 150d | Оператор |
| 119 | 57.1.a.21.17.5 | определить состав информации об абонентах, необходимой оператору связи для осуществления расчетов за услуги связи и рассмотрения претензий, а также порядок передачи указанной информации | 1d? | 2008-08-21 | 2008-08-21 |  | 150d | Оператор |
| 120 | 57.1.a.21.17.6 | определить требование о необходимости соблюдения конфиденциальности передаваемой информации | 1d? | 2008-08-21 | 2008-08-21 |  | 150d | Оператор |
| 121 | 57.1.a.22 | Указать реквизиты ФАС о закреплении ресурса нумерации | 1d? | 2008-08-21 | 2008-08-21 | 31 | 150d | Оператор |
| 122 | 57.1.a.23 | Указать сведения об ожидаемой нагрузке сети электросвязи по видам трафика | 1d? | 2008-08-21 | 2008-08-21 |  | 150d | Оператор |
| 123 | 57.1.a.24 | Указать потребности в средствах связи и сооружениях связи, необходимых для присоединения | 1d? | 2008-08-21 | 2008-08-21 |  | 150d | Оператор |
| 124 | 57.1.a.25 | Указать потребности в использовании технологических систем сети электросвязи | 1d? | 2008-08-21 | 2008-08-21 |  | 150d | Оператор |
| 125 | 57.1.a.26 | **Предоставить схему и описание сети** | 1d? | 2008-08-21 | 2008-08-21 |  | 150d | Оператор |
| 126 | 57.1.a.26.8 | указать монтированную емкость | 1d? | 2008-08-21 | 2008-08-21 |  | 150d | Оператор |
| 127 | 57.1.a.26.9 | указать взаимодействия сети Оператора связи с сетью электросвязи общего пользования | 1d? | 2008-08-21 | 2008-08-21 |  | 150d | Оператор |
| 128 | 57.1.a.26.10 | указать используемые технологические системы | 1d? | 2008-08-21 | 2008-08-21 |  | 150d | Оператор |
| 129 | 57.1.a.26.11 | Представить копии сертификатов соответствия на оборудование связи | 1d? | 2008-08-21 | 2008-08-21 |  | 150d | Оператор |
| 130 | 57.1.b | Выдать акцепт, содержащий проект договора о присоединении сетей электросвязи | 30d | 2008-08-21 | 2008-10-01 |  | 121d | ОАО МГТС |
| 131 | 57.1.c | **Согласовать договор о присоединении сетей электросвязи** | 1d? | 2008-08-21 | 2008-08-21 |  | 150d | Оператор |
| 132 | 57.1.c.11 | Согласовать права и обязанности операторов связи при присоединении сетей электросвязи и их взаимодействии | 1d? | 2008-08-21 | 2008-08-21 |  | 150d | Оператор |
| 133 | 57.1.c.12 | **Согласовать существенные условия присоединения сетей электросвязи и их взаимодействия** | 1d? | 2008-08-21 | 2008-08-21 |  | 150d | Оператор |
| 134 | 57.1.c.12.15 | согласовать технические требования, касающиеся присоединения сетей электросвязи | 1d? | 2008-08-21 | 2008-08-21 |  | 150d | Оператор |
| 135 | 57.1.c.12.16 | согласовать объем, порядок и сроки выполнения работ по присоединению сетей электросвязи и их распределению между взаимодействующими операторами связи | 1d? | 2008-08-21 | 2008-08-21 |  | 150d | Оператор |
| 136 | 57.1.c.12.17 | согласовать порядок пропуска трафика по сетям электросвязи взаимодействующих операторов связи | 1d? | 2008-08-21 | 2008-08-21 |  | 150d | Оператор |
| 137 | 57.1.c.12.18 | согласовать местонахождение точек присоединения сетей электросвязи | 1d? | 2008-08-21 | 2008-08-21 |  | 150d | Оператор |
| 138 | 57.1.c.12.19 | согласовать перечень оказываемых услуг присоединения и услуг по пропуску трафика | 1d? | 2008-08-21 | 2008-08-21 |  | 150d | Оператор |
| 139 | 57.1.c.12.20 | согласовать стоимость услуг присоединения и услуг по пропуску трафика и порядок расчетов за них | 1d? | 2008-08-21 | 2008-08-21 |  | 150d | Оператор |
| 140 | 57.1.c.12.21 | согласовать порядок взаимодействия систем управления сетями электросвязи | 1d? | 2008-08-21 | 2008-08-21 |  | 150d | Оператор |
| 141 | 57.1.c.13 | согласовать порядок рассмотрения споров между операторами связи по вопросам присоединения сетей электросвязи и их взаимодействия | 1d? | 2008-08-21 | 2008-08-21 |  | 150d | Оператор |
| 142 | 57.1.d | Подписание договора о присоединении сетей электросвязи | 40d | 2008-08-21 | 2008-10-15 |  | 111d | Оператор; ОАО МГТС |
| 143 | 57.1.f | Заключить договор аренды каналов связи | 30d | 2008-08-21 | 2008-10-01 |  | 121d | Оператор |

Notes:
- 116: пункт 3 статьи 18 Федерального Закона Российской Федерации от 07.07.2003 №126-ФЗ "О связи" / пункт 3 статьи 19 Федерального Закона Российской Федерации от 07.07.2003 №126-ФЗ "О связи" / п. 40 Постановления Правительства РФ от 28.03.2005 №161 / п. 5. Заключительные положения. Условия присоединения сетей электросвязи к сети электросвязи ОАО МГТС и условия пропуска трафика на местном уровне присоединения
- 117: пункт 3 статьи 18 Федерального Закона Российской Федерации от 07.07.2003 №126-ФЗ "О связи" / пункт 3 статьи 19 Федерального Закона Российской Федерации от 07.07.2003 №126-ФЗ "О связи" / п. 40 Постановления Правительства РФ от 28.03.2005 №161
- 118: п. 41. Постановления Правительства РФ от 28.03.2005 №161
- 121: п. 4. Заключительные положения. Условия присоединения сетей электросвязи к сети электросвязи ОАО МГТС и условия пропуска трафика на местном уровне присоединения
- 122: п. 7. Заключительные положения. Условия присоединения сетей электросвязи к сети электросвязи ОАО МГТС и условия пропуска трафика на местном уровне присоединения
- 123: п. 8. Заключительные положения. Условия присоединения сетей электросвязи к сети электросвязи ОАО МГТС и условия пропуска трафика на местном уровне присоединения
- 124: п. 9. Заключительные положения. Условия присоединения сетей электросвязи к сети электросвязи ОАО МГТС и условия пропуска трафика на местном уровне присоединения
- 125: Заключительные положения. Условия присоединения сетей электросвязи к сети электросвязи ОАО МГТС и условия пропуска трафика на местном уровне присоединения
- 130: пункт 4 статьи 19 Федерального Закона Российской Федерации от 07.07.2003 №126-ФЗ "О связи" / п. 36. Постановления Правительства РФ от 28.03.2005 №161 / Заключительные положения. Условия присоединения сетей электросвязи к сети электросвязи ОАО МГТС и условия пропуска трафика на местном уровне присоединения
- 131: Статья 18 Федерального Закона Российской Федерации от 07.07.2003 №126-ФЗ "О связи"
- 132: п. 3 статьи 18 Федерального Закона Российской Федерации от 07.07.2003 №126-ФЗ "О связи" / п. 15.1. Постановления Правительства РФ от 28.03.2005 №161
- 133: пункт 3 статьи 18 Федерального Закона Российской Федерации от 07.07.2003 №126-ФЗ "О связи" / п. 15.2. Постановления Правительства РФ от 28.03.2005 №161
- 135: пункт 3 статьи 18 Федерального Закона Российской Федерации от 07.07.2003 №126-ФЗ "О связи" / пункт 3 статьи 19 Федерального Закона Российской Федерации от 07.07.2003 №126-ФЗ "О связи"
- 136: пункт 3 статьи 18 Федерального Закона Российской Федерации от 07.07.2003 №126-ФЗ "О связи" / пункт 3 статьи 19 Федерального Закона Российской Федерации от 07.07.2003 №126-ФЗ "О связи"
- 137: пункт 3 статьи 19 Федерального Закона Российской Федерации от 07.07.2003 №126-ФЗ "О связи"
- 138: пункт 3 статьи 18 Федерального Закона Российской Федерации от 07.07.2003 №126-ФЗ "О связи" / пункт 3 статьи 19 Федерального Закона Российской Федерации от 07.07.2003 №126-ФЗ "О связи"
- 139: пункт 3 статьи 18 Федерального Закона Российской Федерации от 07.07.2003 №126-ФЗ "О связи" / пункт 3 статьи 19 Федерального Закона Российской Федерации от 07.07.2003 №126-ФЗ "О связи"
- 140: пункт 3 статьи 19 Федерального Закона Российской Федерации от 07.07.2003 №126-ФЗ "О связи"
- 141: пункт 3 статьи 18 Федерального Закона Российской Федерации от 07.07.2003 №126-ФЗ "О связи" / п. 15.3. Постановления Правительства РФ от 28.03.2005 №161
- 142: пункт 4 статьи 19 Федерального Закона Российской Федерации от 07.07.2003 №126-ФЗ "О связи"

| ID | WBS | Task | Duration | Start | Finish | Predecessors | Total slack | Free slack | Resources |
| --- | --- | --- | --- | --- | --- | --- | --- | --- | --- |
| 144 | 57.1.g | **Заключить договора на предоставление дополнительных ресурсов ОАО МГТС** | 15d | 2008-08-21 | 2008-09-10 |  | 136d |  | Оператор; ОАО МГТС |
| 145 | 57.1.g.4 | Заключить договор на предоставление комплекса ресурсов для обеспечения функционирования технологического оборудования сторонних организаций на объектах ОАО МГТС | 15d | 2008-08-21 | 2008-09-10 |  | 136d |  | Оператор; ОАО МГТС |
| 146 | 57.1.g.5 | Заключить договор об оказании услуг по резервированию места в ЛКС и эксплуатации ЛКС | 15d | 2008-08-21 | 2008-09-10 |  | 136d |  | Оператор; ОАО МГТС |
| 147 | 57.1.g.6 | Заключить договор о предоставлении сетевого ресурса ОАО МГТС для обеспечения доступа Оператора к экстренным оперативным службам и информационно-справочным службам г. Москвы | 15d | 2008-08-21 | 2008-09-10 |  | 136d |  | Оператор; ОАО МГТС |
| 148 | 57.2 | **Выполнить работы по присоединению между операторами** | 76d? | 2008-08-21 | 2008-12-04 |  | 75d |  |  |
| 149 | 57.2.a | Запросить исходные данные в ОАО МГТС для проектирования | 5d | 2008-08-21 | 2008-08-27 |  | 75d | 0d | Оператор |
| 150 | 57.2.b | Подготовить и выдать исходные данные для проектирования | 5d | 2008-08-28 | 2008-09-03 | 149 | 75d | 0d | ОАО МГТС |
| 151 | 57.2.c | Разработать ПСД на присоединение сети связи | 15d | 2008-09-04 | 2008-09-24 | 150 | 75d | 0d | Оператор |
| 152 | 57.2.d | Разработка проекта и присоединение к базовой сети тактовой сетевой синхронизации | 15d | 2008-09-04 | 2008-09-24 | 150 | 75d | 0d | Оператор |
| 153 | 57.2.e | **Согласование ПСД на присоединение сетей связи** | 11d? | 2008-09-25 | 2008-10-09 | 151, 152 | 75d | 0d | ОАО МГТС |
| 154 | 57.2.e.4 | Рассмотрение и подготовка замечаний по ПСД на присоединение сетей связи | 5d | 2008-09-25 | 2008-10-01 |  | 75d | 0d | ОАО МГТС |
| 155 | 57.2.e.5 | Устранение замечаний по ПСД на присоединение сетей связи | 5d | 2008-10-02 | 2008-10-08 | 154 | 75d | 0d | Оператор |
| 156 | 57.2.e.6 | Согласование ПСД на присоединение сетей связи | 1d? | 2008-10-09 | 2008-10-09 | 155 | 75d |  | ОАО МГТС |
| 157 | 57.2.f | Производство СМР для организации присоединения | 30d | 2008-10-10 | 2008-11-20 | 153 | 75d | 0d | Оператор; ОАО МГТС |
| 158 | 57.2.g | Производство ПНР для организации присоединения | 5d | 2008-11-21 | 2008-11-27 | 157 | 75d | 0d | Оператор; ОАО МГТС |
| 159 | 57.2.h | Получить копию разрешения на эксплуатацию присоединяющей сети в точке присоединения согласно ТУ | 5d | 2008-11-28 | 2008-12-04 | 158 | 75d |  | Оператор; ОАО МГТС |
| 160 | 53 | **Выполнить СМР и ПНР сети связи** | 105d? | 2008-08-22 | 2009-01-15 | 7FS-30d | 0d |  | Строительно-монтажная организация |
| 161 | 53.1 | Заключить договор на авторский надзор | 30d | 2008-08-22 | 2008-10-02 |  | 75d |  | Оператор |
| 162 | 53.2 | Заключить договор на выполнение СМР и ПНР | 30d | 2008-08-22 | 2008-10-02 |  | 0d |  | Оператор |
| 163 | 53.3 | **Выполнить СМР сети связи** | 65d | 2008-10-03 | 2009-01-01 | 162 | 0d |  | Строительно-монтажная организация |
| 164 | 53.3.a | Выполнить монтаж СКС | 40d | 2008-10-03 | 2008-11-27 |  | 0d |  |  |
| 165 | 53.3.b | Выполнить монтаж оборудования СТфС | 20d | 2008-11-07 | 2008-12-04 | 164FS-15d | 0d |  |  |
| 166 | 53.3.c | Выполнить монтаж оборудования СПД | 20d | 2008-11-07 | 2008-12-04 | 164FS-15d | 0d |  |  |
| 167 | 53.3.d | Выполнить монтаж оборудования СКТВ | 20d | 2008-11-07 | 2008-12-04 | 164FS-15d | 20d |  |  |
| 168 | 53.3.e | Выполнить установку системы управления сетью | 20d | 2008-12-05 | 2009-01-01 | 165, 166 | 0d |  |  |
| 169 | 53.3.f | Выполнить установку системы биллинга | 20d | 2008-12-05 | 2009-01-01 | 165, 166 | 0d |  |  |

Notes:
- 145: п. 3.3.1. Условия присоединения сетей электросвязи к сети электросвязи МГТС и условия пропуска трафика на местном уровне присоединения / п. 3.1. Условия использования задействуемого в ходе исполнения договора о присоединении сетей электросвязи имущества
- 146: п. 3.2. Условия использования задействуемого в ходе исполнения договора о присоединении сетей электросвязи имущества
- 147: п. 3.4. Условия использования задействуемого в ходе исполнения договора о присоединении сетей электросвязи имущества
- 148: Условия присоединения сетей электросвязи к сети электросвязи МГТС и условия пропуска трафика на местном уровне присоединения

| ID | WBS | Task | Duration | Start | Finish | Predecessors | Total slack | Free slack | Resources |
| --- | --- | --- | --- | --- | --- | --- | --- | --- | --- |
| 170 | 53.4 | **Выполнить ПНР сети связи** | 10d? | 2009-01-02 | 2009-01-15 | 163 | 0d |  | Строительно-монтажная организация |
| 171 | 53.4.a | **Получение разрешения на эксплутацию РЭС** | 1d? | 2009-01-02 | 2009-01-02 |  | 9d |  | Оператор |
| 172 | 53.4.a.1 | уведомить ГРЧС о первом включении РЭС | 1d? | 2009-01-02 | 2009-01-02 |  | 9d |  | Оператор |
| 173 | 53.4.a.2 | измерить параметры РЭС | 1d? | 2009-01-02 | 2009-01-02 |  | 9d |  | Оператор |
| 174 | 53.4.a.3 | выдать разрешение на эксплуатацию РЭС | 1d? | 2009-01-02 | 2009-01-02 |  | 9d |  | Россвязьохранкультура |
| 175 | 53.4.b | Провести испытания сооружения связи, до его приемки в эксплуатацию, на соответствие нормативным документам Минсвязи России, а при их отсутствии - технической документации производителя оборудования | 5d | 2009-01-02 | 2009-01-08 |  | 0d |  | Строительно-монтажная организация |
| 176 | 53.4.c | Подшить протоколы измерений в исполнительную документацию | 5d | 2009-01-09 | 2009-01-15 | 175 | 0d |  | Строительно-монтажная организация |
| 177 | 35 | **Обеспечить организационную готовность оператора к оказанию услуг связи** | 246d? | 2008-04-10 | 2009-03-19 |  | 0d |  | Оператор |
| 178 | 35.18 | Утвердить мероприятия по организации эксплуатации сети связи | 10d | 2008-07-10 | 2008-07-23 | 40 | 106d | 0d | Оператор |
| 179 | 35.19 | **Разработать эксплуатационную документацию** | 20d | 2008-10-23 | 2008-11-19 | 66, 178 | 41d | 0d | Оператор |
| 180 | 35.19.b | Разработать инструкцию по эксплуатации объекта в целом | 20d | 2008-10-23 | 2008-11-19 |  | 41d |  | Оператор |
| 181 | 35.19.c | Подготовить инструкции по эксплуатации оборудования | 20d | 2008-10-23 | 2008-11-19 |  | 41d |  | Оператор |
| 182 | 35.19.e | Разработать журнал регистрации повреждений | 20d | 2008-10-23 | 2008-11-19 |  | 41d |  | Оператор |
| 183 | 35.19.f | Разработать журнал учета жалоб абонентов | 20d | 2008-10-23 | 2008-11-19 |  | 41d |  | Оператор |
| 184 | 35.19.g | Разработать журнал контроля устранения причин жалоб и претензий | 20d | 2008-10-23 | 2008-11-19 |  | 41d |  | Оператор |
| 185 | 35.19.h | Разработать перечень средств измерений, необходимых для метрологического обеспечения эксплуатации объекта связи | 20d | 2008-10-23 | 2008-11-19 |  | 41d |  | Оператор |
| 186 | 35.19.i | Разработать положение о метрологической службе оператора связи | 20d | 2008-10-23 | 2008-11-19 |  | 41d | 0d | Оператор |
| 187 | 35.17 | **Аттестовать рабочие места по условиям труда** | 45d? | 2009-01-16 | 2009-03-19 | 160, 178 | 0d |  | Оператор |
| 188 | 35.17.d | Подготовить приказ о создании аттестационной комиссии | 1d? | 2009-01-16 | 2009-01-16 |  | 44d |  | Оператор |
| 189 | 35.17.c | **Аттестовать рабочие места по условиям труда (по уровню освещенности, шума, достаточности площади)** | 44d? | 2009-01-16 | 2009-03-18 |  | 0d |  | Оператор |
| 190 | 35.17.c.1 | **Измеренить параметры опасных и вредных производственных факторов, определение показателей тяжести и напряженности трудового процесса** | 44d | 2009-01-16 | 2009-03-18 |  | 0d |  | Аккредитованные лаборатории |
| 191 | 35.17.c.1.1 | Получить экспертное заключение в Роспотребнадзоре | 44d | 2009-01-16 | 2009-03-18 |  | 0d |  | Роспотребнадзор |
| 192 | 35.17.c.2 | Оценить травмобезопасность рабочих мест | 1d? | 2009-01-16 | 2009-01-16 |  | 43d |  | Оператор |
| 193 | 35.17.c.3 | Оценить обеспеченность работников средствами индивидуальной защиты | 1d? | 2009-01-16 | 2009-01-16 |  | 43d |  | Оператор |
| 194 | 35.17.c.4 | Оценить фактическое состояние условий труда на рабочих местах | 1d? | 2009-01-16 | 2009-01-16 |  | 43d |  | Оператор |
| 195 | 35.17.e | Оформить результаты аттестации рабочих мест по условиям труда | 1d? | 2009-03-19 | 2009-03-19 | 189 | 0d |  | Оператор |

Notes:
- 170: п. 5.3. Приказа Минсвязи от 9.09.2002 №113
- 175: п. 5.4. Приказа Минсвязи от 9.09.2002 №113 / Измерительное оборудование должно пройти государственную поверку и быть внесено в реестр средств измерений / Эксплуатационные нормы на электрические параметрыканалов сети ТфОП утверждены Приказом Госкомсвязи России от 05.04.199 №54
- 177: п. 9. Приказа Главгоссвязьнадзора России от 03.03.1999 №11
- 179: Эксплуатационная документация, прошедшая государственную экспертизу в составе проекта не может вызвать претензий со стороны Россвязьохранкультуры
- 186: Федеральный Закон Российской Федерации "О единстве средств измерений" / Федеральный Закон Российской Федерации от 27.04.1993 №4871-I "Об обеспечении единства измерений"
- 187: Постановление труда и социального развития Российской Федерации от 14 марта 1997 г. №12 / п. 10.4. Приказа Главгоссвязьнадзора России от 03.03.1999 №11 / п. 5.4. Приказа Минсвязи от 9.09.2002 №113 / ст. 212 Трудового кодекса Российской Федерации / ст. 14 Федерального закона "Об основах охраны труда в Российской Федерации"/ п. 2.9.7. Распоряжения Вице-мэра от 23.06.2004 №10-РВМ
- 188: п. 3. Распоряжения Вице-мэра от 23.06.2004 №10-РВМ
- 189: п. 10.4. Приказа Главгоссвязьнадзора России от 03.03.1999 №11 / п. 5.4. Приказа Минсвязи от 9.09.2002 №113
- 190: п. 10.4. Приказа Главгоссвязьнадзора России от 03.03.1999 №11 / п. 5.4. Приказа Минсвязи от 9.09.2002 №113 / п.2.6., п. 4.4. Распоряжения Вице-Мэра от 23.06.2004 №10-РВМ / Примечание: / Лаборатории должны быть аккредитованы в Системе сертификации работ по охране труда в организациях, Системе аккредитации ГОСТ Р, Системе аккредитации аналитических лабораторий, Системе аккредитации государственной санитарно-эпидемиологической службы
- 191: Приказ Роспотребнадзора от 19.07.2007 №224
- 192: п. 4.5. Распоряжения Вице-Мэра от 23.06.2004 №10-РВМ
- 193: п. 4.6. Распоряжения Вице-Мэра от 23.06.2004 №10-РВМ
- 194: п. 4.7. Распоряжения Вице-Мэра от 23.06.2004 №10-РВМ / Руководство Р 2.2.755-99 "Гигиенические критерии оценки и классификация условий труда по показателям вредности и опасности факторов производственной среды, тяжести и напряженности трудового процесса"
- 195: п.5., п.6. Распоряжения Вице-Мэра от 23.06.2004 №10-РВМ

| ID | WBS | Task | Duration | Start | Finish | Predecessors | Total slack | Free slack | Resources |
| --- | --- | --- | --- | --- | --- | --- | --- | --- | --- |
| 196 | 35.7 | **Формализовать работу персонала** | 45d | 2008-11-20 | 2009-01-21 | 66, 178, 179 | 41d |  | Оператор |
| 197 | 35.7.a | Разработать штатное расписание | 20d | 2008-11-20 | 2008-12-17 |  | 41d | 0d | Оператор |
| 198 | 35.7.b | Разработать должностные инструкции | 20d | 2008-12-18 | 2009-01-14 | 197 | 41d | 0d | Оператор |
| 199 | 35.7.c | Провести внутреннюю аттестацию сотрудников соответствию занимаемой должности | 5d | 2009-01-15 | 2009-01-21 | 198, 178 | 41d |  | Оператор |
| 200 | 35.1 | **Обучить персонал** | 22d | 2008-07-24 | 2008-08-22 | 178 | 149d |  | Оператор |
| 201 | 35.1.a | Обучить сотрудников, подтердить профессиональную квалификацию сотрудников | 22d | 2008-07-24 | 2008-08-22 |  | 149d |  | Оператор |
| 202 | 35.1.b | **Обучить персонал правилам техники безопасности и охраны труда** | 22d | 2008-07-24 | 2008-08-22 |  | 149d |  | Оператор |
| 203 | 35.1.b.1 | Получить удостоверения о проверке знаний по технике электробезопасности, квалификационная группа персонала не ниже III до 1000 В; лиц, имеющих право выдавать наряды (руководители) – не ниже IV до 1000 В | 22d | 2008-07-24 | 2008-08-22 |  | 149d |  | Оператор |
| 204 | 35.1.b.2 | Получить удостоверения о проверке знаний по охране труда | 22d | 2008-07-24 | 2008-08-22 |  | 149d |  | Оператор |
| 205 | 35.1.b.3 | Заполнить журнал инструктажей сотрудников | 2d | 2008-07-24 | 2008-07-25 |  | 169d |  | Оператор |
| 206 | 35.1.b.5 | Обеспечить сотрудников средствами индивидуальной защиты, специальной одежды и обуви, медицинских аптечек | 20d | 2008-07-24 | 2008-08-20 |  | 151d |  | Оператор |
| 207 | 35.1.b.4 | Разработать Инструкции по охране труда и технике безопасности на предприятии | 10d | 2008-07-24 | 2008-08-06 |  | 161d |  | Оператор |
| 208 | 35.6 | **Обеспечить соблюдение единства средств измерений** | 30d | 2008-11-20 | 2008-12-31 | 178, 186 | 56d |  | Оператор |
| 209 | 35.6.b | Утвердить руководителем предприятия Положения о метрологической службе | 5d | 2008-11-20 | 2008-11-26 |  | 81d |  | Оператор |
| 210 | 35.6.a | Назначить главного метролога приказом руководителя | 5d | 2008-11-20 | 2008-11-26 |  | 81d |  | Оператор |
| 211 | 13.6.3 | Заключить договор на техническое обслуживание контрольно-измерительной аппаратуры | 30d | 2008-11-20 | 2008-12-31 |  | 56d |  |  |
| 212 | 35.11 | **Заключить договора аренды технологических помещений (площадок) по выданным ТУ, аренды оборудования и т.д.** | 90d | 2008-04-10 | 2008-08-13 |  | 126d | 0d | Оператор |
| 213 | 35.11.a | Заключить договор аренды недвижимого имущества | 30d | 2008-04-10 | 2008-05-21 |  | 126d | 0d | Оператор; Застройщик |
| 214 | 35.11.b | Выполнить государственную регистрацию договора аренды недвижимого имущества, заключаемого на срок более одного года | 60d | 2008-05-22 | 2008-08-13 | 213 | 126d |  | Оператор |
| 215 | 35.12 | **Разработать условия договорных отношений** | 30d? | 2008-08-14 | 2008-09-24 | 212 | 126d |  | Оператор |
| 216 | 35.12.a | Разработать проект типового договора с физическими лицами | 30d | 2008-08-14 | 2008-09-24 |  | 126d |  | Оператор |
| 217 | 35.12.b | Разработать проект типового договора с юридическими лицами | 30d | 2008-08-14 | 2008-09-24 |  | 126d |  | Оператор |
| 218 | 35.12.c | Утвердить тарифы приказом руководителя оператора связи | 30d | 2008-08-14 | 2008-09-24 |  | 126d |  | Оператор |
| 219 | 35.12.d | Утвердить порядок предоставления бесплатной связи для выова экстренных служб приказом руководителя оператора связи | 30d | 2008-08-14 | 2008-09-24 |  | 126d |  | Оператор |
| 220 | 35.12.e | Утвердить порядок предоставления льгот, предусмотренных действующим законодательством приказом руководителя оператора связи | 30d | 2008-08-14 | 2008-09-24 |  | 126d |  | Оператор |
| 221 | 13.8.6 | Определить базу расчета обязательных отчислений в резерв универсального обслуживания | 1d? | 2008-08-14 | 2008-08-14 |  | 155d |  |  |
| 222 | 35.14 | Предоставить статистическую отчетность | 5d | 2008-04-10 | 2008-04-16 |  | 241d |  | Оператор |

Notes:
- 196: п. 3.11. приложений 9, 10 к Приказу Главгоссвязьнадзора России от 03.03.1999 №11
- 198: п. 3.11. приложений 9, 10 к Приказу Главгоссвязьнадзора России от 03.03.1999 №11
- 203: Обучение проводится в специализированных учебных комбинатах. Удостоверения п.1 действительны в течение одного года, п. 2 в течение трех лет
- 204: Обучение проводится в специализированных учебных комбинатах. Удостоверения п.1 действительны в течение одного года, п. 2 в течение трех лет
- 207: Инструкции должны располагаться в местах, доступных для ознакомления персоаналом.
- 208: п. 3.9. приложений 9, 10 к Приказу Главгоссвязьнадзора России от 03.03.1999 №11
- 214: Статья 651 Гражданского кодекса Российской Федерации

| ID | WBS | Task | Duration | Start | Finish | Predecessors | Total slack | Resources |
| --- | --- | --- | --- | --- | --- | --- | --- | --- |
| 223 | 56 | **Обеспечить ввод узлов связи в эксплуатацию** | 36d? | 2009-03-20 | 2009-05-08 | 1, 7, 21, 30, 37, 60, 66, 72, 95, 102, 160, 177 | 0d | Оператор |
| 224 | 56.2 | **Работа приемочной комиссии законченного строительством объекта недвижимости** | 26d? | 2009-03-20 | 2009-04-24 |  | 0d | Приемочная Комиссия |
| 225 | 56.2.a | **Предоставить необходимые документы для приемочной комиссии** | 1d? | 2009-03-20 | 2009-03-20 |  | 9d | Оператор |
| 226 | 56.2.a.1 | предоставить справку о выполнении условий действия лицезии (оригинал) | 1d? | 2009-03-20 | 2009-03-20 |  | 9d | Оператор |
| 227 | 56.2.a.2 | предоставить акт рабочей комиссии по вводу в эксплуатацию (оригинал - для подписания представителем Россвязьохранкультуры) | 1d? | 2009-03-20 | 2009-03-20 |  | 9d | Застройщик |
| 228 | 56.2.a.3 | предоставить лицензии на осуществление деятельности по оказанию услуг связи | 1d? | 2009-03-20 | 2009-03-20 |  | 9d | Оператор |
| 229 | 56.2.a.4 | предоставить свидетельство о регистрации лицензиата | 1d? | 2009-03-20 | 2009-03-20 | 21 | 9d | Оператор |
| 230 | 56.2.a.5 | **предоставить первичные документы, подтверждающие соответствие выполненных работ и применяемого оборудования установленным требованиям** | 1d? | 2009-03-20 | 2009-03-20 | 40, 66, 160 | 9d | Оператор |
| 231 | 56.2.a.5.1 | предоставить копии сертификатов соответствия системы сертификации «Связь» на все технические средства вводимых в эксплуатацию объектов связи | 1d? | 2009-03-20 | 2009-03-20 | 40, 66, 160 | 9d | Строительно-монтажная организация |
| 232 | 56.2.a.5.2 | **предоставить справку о применяемых автоматизированных системах расчетов (АСР) либо справка об отсутствии АСР (оригинал)** | 1d? | 2009-03-20 | 2009-03-20 | 40, 66, 160 | 9d | Оператор |
| 233 | 56.2.a.5.2.1 | предоставить структурную схему АСР | 1d? | 2009-03-20 | 2009-03-20 |  | 9d | Оператор |
| 234 | 56.2.a.5.2.2 | предоставить ТУ | 1d? | 2009-03-20 | 2009-03-20 |  | 9d | Оператор |
| 235 | 56.2.a.5.2.3 | предоставить формуляр с заполненной таблицей проверок по контрольному примеру по метрологии | 1d? | 2009-03-20 | 2009-03-20 |  | 9d | Оператор |
| 236 | 56.2.a.5.2.4 | предоставить приказ о периодичности проведения метрологической поверки (верности временных интервалов, выдаваемых в АПК АСР) | 1d? | 2009-03-20 | 2009-03-20 |  | 9d | Оператор |
| 237 | 56.2.a.6 | предоставить утвержденную проектную документацию | 1d? | 2009-03-20 | 2009-03-20 | 1, 40, 66 | 9d | Оператор |
| 238 | 56.2.a.7 | предоставить приказы об утверждении проектной документации | 1d? | 2009-03-20 | 2009-03-20 | 1, 40, 66 | 9d | Оператор |
| 239 | 56.2.a.8 | предоставить заключение государственной экспертизы проекта | 1d? | 2009-03-20 | 2009-03-20 | 40 | 9d | Оператор |
| 240 | 56.2.a.9 | предоставить утвержденный акт приемки законченных СМР объекта связи (акт рабочей комиссии) | 1d? | 2009-03-20 | 2009-03-20 | 160, 7 | 9d | Оператор |
| 241 | 56.2.a.10 | предоставить утвержденный акт (протокол) по результатам испытаний сооружения связи, проведенных оператором, до экспертизы | 1d? | 2009-03-20 | 2009-03-20 | 7, 160 | 9d | Оператор |
| 242 | 56.2.a.11 | предоставить утвержденные оператором схему соединений и спецификацию сооружения связи, содержащую сведения о назначении, составе средств связи, условия эксплуатации и технические характеристики сооружения связи | 1d? | 2009-03-20 | 2009-03-20 | 40, 66 | 9d | Оператор |
| 243 | 56.2.a.12 | **предоставить комплект эксплуатационной документации на сооружение, включая инструкции по эксплуатации средств связи** | 1d? | 2009-03-20 | 2009-03-20 | 6, 179 | 9d | Оператор |
| 244 | 56.2.a.12.7 | предоставить схему энергоснабжения | 1d? | 2009-03-20 | 2009-03-20 |  | 9d | Оператор |
| 245 | 56.2.a.12.8 | предоставить однолинейную схему | 1d? | 2009-03-20 | 2009-03-20 |  | 9d | Оператор |
| 246 | 56.2.a.12.9 | предоставить акт разграничения балансовой принадлежности и эксплуатационной ответственности между энергоснабжающей организацией и потребителем | 1d? | 2009-03-20 | 2009-03-20 |  | 9d | Оператор |
| 247 | 56.2.a.12.10 | предоставить журнал содержания и эксплуатации аккумуляторных батарей | 1d? | 2009-03-20 | 2009-03-20 |  | 9d | Оператор |
| 248 | 56.2.a.12.11 | предоставить журнал учета повреждений | 1d? | 2009-03-20 | 2009-03-20 |  | 9d | Оператор |
| 249 | 56.2.a.12.12 | предоставить порядок работы с письмами, обращениями и жалобами пользователей услугами связи | 1d? | 2009-03-20 | 2009-03-20 |  | 9d | Оператор |
| 250 | 56.2.a.13 | предоставить разрешения органов ГРЧС на использование радиочастот и на эксплуатацию РЭС | 1d? | 2009-03-20 | 2009-03-20 | 33 | 9d | Оператор |

Notes:
- 224: п. 5.4. Приказа Минсвязи от 9.09.2002 №113
- 225: п. 5.4. Приказа Минсвязи от 9.09.2002 №113; / п.4.2. Приказа Минсвязи от 15.12.1993 №61 (утратил силу)
- 228: п. 5.4. Приказа Минсвязи от 9.09.2002 №113
- 230: п. 5.4. Приказа Минсвязи от 9.09.2002 №113
- 232: п. 15.3. ОТТ
- 237: п. 5.4. Приказа Минсвязи от 9.09.2002 №113
- 239: п. 5.4. Приказа Минсвязи от 9.09.2002 №113
- 240: п.4.2. Приказа Минсвязи от 15.12.1993 №61 (утратил силу)
- 241: п. 5.4. Приказа Минсвязи от 9.09.2002 №113 / п.4.2. Приказа Минсвязи от 15.12.1993 №61 (утратил силу)
- 242: п.4. приложения 3 Приказа Минсвязи от 16.01.2003 №3 (утратил силу)
- 243: п. 5.4. Приказа Минсвязи от 9.09.2002 №113
- 250: п. 5.4. Приказа Минсвязи от 9.09.2002 №113

| ID | WBS | Task | Duration | Start | Finish | Predecessors | Total slack | Resources |
| --- | --- | --- | --- | --- | --- | --- | --- | --- |
| 251 | 56.2.a.14 | **Предоставить документы по помещениям** | 1d? | 2009-03-20 | 2009-03-20 | 7 | 9d | Оператор |
| 252 | 56.2.a.14.7 | предоставить акт сдачи помещения под монтаж | 1d? | 2009-03-20 | 2009-03-20 | 7 | 9d | Оператор |
| 253 | 56.2.a.14.8 | предоставить санитарный паспорт на сооружение связи (при наличии РЭС за исключением систем кабельного телевидения) | 1d? | 2009-03-20 | 2009-03-20 |  | 9d | Оператор |
| 254 | 56.2.a.14.9 | предоставить заключение Роспотребнадзора о допуске помещений к эксплуатации в качестве узлов связи | 1d? | 2009-03-20 | 2009-03-20 |  | 9d | Оператор |
| 255 | 56.2.a.14.10 | предоставить заключение МЧС о допуске помещений к эксплуатации в качестве узлов связи (сведения о противопожарных мероприятиях либо заключение МЧС) | 1d? | 2009-03-20 | 2009-03-20 |  | 9d | Оператор |
| 256 | 56.2.a.14.11 | предоставить аттестаты рабочих мест | 1d? | 2009-03-20 | 2009-03-20 | 187 | 9d | Оператор |
| 257 | 56.2.a.15 | **предоставить документы, подтверждающие подготовку специалистов для работы на оборудовании, входящем в состав сооружения, в том числе знание ими правил технической эксплуатации, техники безопасности и охраны труда** | 1d? | 2009-03-20 | 2009-03-20 | 15, 188, 195, 198, 205, 206, 207 | 9d | Оператор |
| 258 | 56.2.a.15.6 | предоставить должностные инструкции персонала | 1d? | 2009-03-20 | 2009-03-20 | 198 | 9d | Оператор |
| 259 | 56.2.a.15.7 | предоставить приказ о назначении лиц, ответственных за электрохозяйство | 1d? | 2009-03-20 | 2009-03-20 | 15 | 9d | Оператор |
| 260 | 56.2.a.15.8 | предоставить приказ о создании аттестационной комиссии | 1d? | 2009-03-20 | 2009-03-20 | 188 | 9d | Оператор |
| 261 | 56.2.a.15.9 | предоставить протоколы внутренней аттестационной комиссии | 1d? | 2009-03-20 | 2009-03-20 | 195 | 9d | Оператор |
| 262 | 56.2.a.15.10 | предоставить инструкции по техники безопасности и охране труда | 1d? | 2009-03-20 | 2009-03-20 | 207 | 9d | Оператор |
| 263 | 56.2.a.15.11 | предоставить журнал учета и содержания средств защиты (укомплектованность средствами защиты) | 1d? | 2009-03-20 | 2009-03-20 | 206 | 9d | Оператор |
| 264 | 56.2.a.15.12 | предоставить журналы инструктажа и проверке знаний по технике безопасности и охране труда (наличие у персонала удостоверений по охране труда и технике безопасности) | 1d? | 2009-03-20 | 2009-03-20 | 205 | 9d | Оператор |
| 265 | 56.2.a.15.13 | продемонстрировать укомплектованность средствами оказания первой помощи (аптечки) | 1d? | 2009-03-20 | 2009-03-20 | 206 | 9d | Оператор |
| 266 | 56.2.a.16 | **Предоставить документы по присоединению сетей электросвязи** | 1d? | 2009-03-20 | 2009-03-20 | 60, 103, 148 | 9d | Оператор |
| 267 | 56.2.a.16.1 | предоставить договора между операторами на присоединение к соответствующей сети связи | 1d? | 2009-03-20 | 2009-03-20 | 103 | 9d | Оператор |
| 268 | 56.2.a.16.2 | предоставить перечень взаимодействующих сетей с указанием адресов точек присоединения, номеров лицензий и номеров разрешений на эксплуатацию взаимодействующих сетей в точках присоединения | 1d? | 2009-03-20 | 2009-03-20 | 148 | 9d | Оператор |
| 269 | 56.2.a.16.3 | предоставить копии лицензий и разрешений на эксплуатацию присоединяющих и присоединяемых сетей связи | 1d? | 2009-03-20 | 2009-03-20 | 148 | 9d | Оператор |
| 270 | 56.2.a.16.4 | предоставить технические условия на присоединение, выданные оператором присоединяющих сетей связи | 1d? | 2009-03-20 | 2009-03-20 | 60 | 9d | Оператор |
| 271 | 56.2.a.17 | Предоставить договора с вещателем | 1d? | 2009-03-20 | 2009-03-20 |  | 9d | Оператор |
| 272 | 56.2.a.18 | **Предоставить документы по метрологическому обеспечению** | 1d? | 2009-03-20 | 2009-03-20 | 181, 186, 211 | 9d | Оператор |
| 273 | 56.2.a.18.4 | предоставить положение о метрологической службе | 1d? | 2009-03-20 | 2009-03-20 | 186 | 9d | Оператор |
| 274 | 56.2.a.18.5 | предоставить перечень средств измерений, предусмотренных инструкциями по эксплуатации, и сведений об их поверке | 1d? | 2009-03-20 | 2009-03-20 | 181 | 9d | Оператор |
| 275 | 56.2.a.18.6 | предоставить договора на техническое обслуживание контрольно-измерительной аппаратуры | 1d? | 2009-03-20 | 2009-03-20 | 211 | 9d | Оператор |

Notes:
- 251: п. 10.4. Приказа Главгоссвязьнадзора России от 03.03.1999 №11 / п. 5.4. Приказа Минсвязи от 9.09.2002 №113 / п.4.2. Приказа Минсвязи от 15.12.1993 №61 (утратил силу)
- 252: п.4.2. Приказа Минсвязи от 15.12.1993 №61 (утратил силу)
- 253: п. 5.4. Приказа Минсвязи от 9.09.2002 №113
- 257: п. 5.4. Приказа Минсвязи от 9.09.2002 №113
- 266: п. 5.4. Приказа Минсвязи от 9.09.2002 №113
- 267: п. 5.4. Приказа Минсвязи от 9.09.2002 №113
- 271: п. 18 приложения 1 к Приказу Мининформсвязи от 10.11.2005 №128
- 272: п. 5.4. Приказа Минсвязи от 9.09.2002 №113
- 274: п. 5.4. Приказа Минсвязи от 9.09.2002 №113
- 275: п.4.2. Приказа Минсвязи от 15.12.1993 №61 (утратил силу)

| ID | WBS | Task | Duration | Start | Finish | Predecessors | Total slack | Resources |
| --- | --- | --- | --- | --- | --- | --- | --- | --- |
| 276 | 56.2.a.19 | **предоставить документы, подтверждающие организацию мероприятий по внедрению СОРМ** | 1d? | 2009-03-20 | 2009-03-20 | 72 | 9d | Оператор |
| 277 | 56.2.a.19.4 | предоставить согласованный с УФСБ план мероприятий по внедрению СОРМ | 1d? | 2009-03-20 | 2009-03-20 | 73 | 9d | Оператор |
| 278 | 56.2.a.19.5 | предоставить акт ввода ТСС СОРМ в эксплутацию | 1d? | 2009-03-20 | 2009-03-20 | 74 | 9d | Оператор |
| 279 | 56.2.a.19.6 | предоставить письмо уФСБ об отсутствии возражений против начала эксплуатации объекта связи до реализации СОРМ | 1d? | 2009-03-20 | 2009-03-20 | 75 | 9d | Оператор |
| 280 | 56.2.a.20 | предоставить приказ об утверждении порядка предоставления льгот | 1d? | 2009-03-20 | 2009-03-20 | 215 | 9d | Оператор |
| 281 | 56.2.a.21 | предоставить статистическую отчетность | 1d? | 2009-03-20 | 2009-03-20 | 222 | 9d | Оператор |
| 282 | 56.2.a.22 | Предоставить сведения о базе расчета обязательных отчислений в резерв универсального обслуживания | 1d? | 2009-03-20 | 2009-03-20 | 221 | 9d | Оператор |
| 283 | 56.2.b | **проведение экспертизы объекта связи** | 10d | 2009-03-20 | 2009-04-02 |  | 0d | Россвязьохранкультура |
| 284 | 56.2.b.1 | обследование сооружений связи | 5d | 2009-03-20 | 2009-03-26 |  | 5d | Россвязьохранкультура |
| 285 | 56.2.b.2 | проведение измерений | 10d | 2009-03-20 | 2009-04-02 |  | 0d | Россвязьохранкультура |
| 286 | 56.2.b.3 | проверка наличия необходимых документов | 10d | 2009-03-20 | 2009-04-02 |  | 0d | Россвязьохранкультура |
| 287 | 56.2.c | подготовить Заключения по результатам работы в приемочной комиссии | 15d | 2009-04-03 | 2009-04-23 | 225, 283 | 0d | Россвязьохранкультура |
| 288 | 56.2.d | утвердить Акт приемки сооружения связи | 1d? | 2009-04-24 | 2009-04-24 | 287 | 0d | Приемочная Комиссия |
| 289 | 56.3 | **Выдать разрешение на эксплуатацию сооружения связи** | 10d? | 2009-04-27 | 2009-05-08 | 224 | 0d | Россвязьохранкультура |
| 290 | 56.3.a | Устранение замечаний комиссии | 1d? | 2009-04-27 | 2009-04-27 |  | 9d | Оператор |
| 291 | 56.3.b | Предоставление перечня перечень технических средств, установленных на сооружении связи, с данными, необходимыми для их регистрации органами госсвязьнадзора | 1d? | 2009-04-27 | 2009-04-27 |  | 9d | Оператор |
| 292 | 56.3.c | Оформление и выдача разрешения на эксплуатацию сооружения связи | 10d | 2009-04-27 | 2009-05-08 |  | 0d | Россвязьохранкультура |
| 293 | 17 | Начало оканазния услуг связи | 1d? | 2009-05-11 | 2009-05-11 | 223 | 0d | Оператор |
| 294 | 55 | **Пройти первичный контроль надзорных органов** | 30d? | 2009-05-12 | 2009-06-22 | 293 | 0d | Оператор |
| 295 | 55.1 | Заключить договор на осуществление контроля лицензируемой деятельности в области связи | 30d | 2009-05-12 | 2009-06-22 |  | 0d | Оператор; Россвязьохранкультура |
| 296 | 55.2 | Выполнить государственную экспертизу условий труда | 1d? | 2009-05-12 | 2009-05-12 |  | 29d | Комитет общественных связей города Москвы |
| 297 | 55.3 | **Пройти контроль за выполнением требований пожарной безопасности** | 1d? | 2009-05-12 | 2009-05-12 |  | 29d | Оператор |
| 298 | 55.3.a | Предоставить разрешение на строительство | 1d? | 2009-05-12 | 2009-05-12 |  | 29d | Оператор |
| 299 | 55.3.b | Предоставить заключение госэкспертизы проектной документации | 1d? | 2009-05-12 | 2009-05-12 |  | 29d | Оператор |
| 300 | 55.3.c | Предоставить разрешение на ввод объекта в эксплуатацию | 1d? | 2009-05-12 | 2009-05-12 |  | 29d | Оператор |

Notes:
- 276: п. 5.4. Приказа Минсвязи от 9.09.2002 №113
- 282: Правительство РФ подписало постановление, дополняющее перечень лицензионных условий для оказания услуг связи сведениями об отчислениях средств в резерв универсального обслуживания, сообщает РБК. Соответствующее постановление от 24 января 2008 г. "О внесении изменений в перечни лицензионных условий осуществления деятельности в области оказания соответствующих услуг связи" подписал премьер-министр РФ Виктор Зубков. Соответствующие поправки, подготовленные Федеральным агентством связи (Россвязь), внесены в постановление правительства от 18 февраля 2005 г. "Об утверждении перечня наименований услуг связи, вносимых в лицензии, и перечней лицензионных условий". (http://telecom.cnews.ru/news/line/index.shtml?2008/01/29/285561)
- 283: пп. 3, 4.3. Приказа Минсвязи от 15.12.1993 №61 (утратил силу)
- 284: п. 3.4. Приказа Минсвязи от 16.01.2003 №3 (утратил силу)
- 285: пп. 3.4., 3.6. Приказа Минсвязи от 16.01.2003 №3 (утратил силу)
- 286: п. 3.4. Приказа Минсвязи от 16.01.2003 №3 (утратил силу)
- 287: п. 5.5. Приказа Минсвязи от 9.09.2002 №113; / п. 12. Приложения 2 к Приказу Главгоссвязьнадзора России от 03.03.1999 №11; / Приложение 8 к Приказу Главгоссвязьнадзора России от 03.03.1999 №11
- 288: п. 3.8. Приказа Минсвязи от 9.09.2002 №113
- 289: пп. 3.9., 3.11. Приказа Минсвязи от 9.09.2002 №113 / Приказ Россвязьохранкультуры от 2.10.2007 №199
- 290: п. 3.11. Приказа Минсвязи от 9.09.2002 №113
- 291: п. 6.1.1. Приказа Минсвязи от 16.01.2003 №3 (утратил силу)
- 292: п. 5.8. Приказа Минсвязи от 9.09.2002 №113 / в т.ч.: ...Разрешение на эксплуатацию сооружения связи одновременно является свидетельством о регистрации входящих в его состав средств связи (технических средств).
- 293: пп. 3.10. Приказа Минсвязи от 9.09.2002 №113
- 295: п. 6.1. Приказа Главгоссвязьнадзора России от 03.03.1999 №11
- 296: Постановление Правительства Российской Федерации от 25.04.2003 №244 / Постановление Минтруда России от 24 апреля 2002 г. №28 "О создании Системы сертификации работ по охране труда в организациях" / Распоряжение Правительства Москвы от 29.07.2002 №1080-РП
- 297: Письмо МЧС от 28.12.2006 №43-4357-19
